# BEDs_schedule_2012

Schedule from MS Project, 2014-01-06 to 2014-12-15.

## Calendars

- Standard: Mon-Fri 08:00-12:00, 13:00-17:00; Sat-Sun off.

## Schedule

| ID | WBS | Task | Type | Duration | Start | Finish | Total slack |
| --- | --- | --- | --- | --- | --- | --- | --- |
| 1 | 1 | **Software** |  | 18d | 2014-02-03 | 2014-02-26 | 0d |
| 2 | 1.1 | Integrate Globalstar | manual | 10d | 2014-02-03 | 2014-02-14 |  |
| 3 | 1.2 | Test Globalstar for human interaction | manual | 18d | 2014-02-03 | 2014-02-26 |  |
| 4 | 2 | **Electrical** |  | 16d | 2014-01-13 | 2014-02-03 | 0d |
| 5 | 2.1 | Clean up acoustics wiring | manual | 16d | 2014-01-13 | 2014-02-03 |  |
| 6 | 3 | **Mechanical** |  | 10d? | 2014-01-20 | 2014-01-31 | 0d |
| 7 | 3.1 | Fair xducer | manual | 10d | 2014-01-20 | 2014-01-31 |  |
| 8 | 3.2 | Fabricate xducer/fairing for SV3 | manual | 1d? | 2014-01-20 | 2014-01-20 |  |
| 9 | 4 | **Systems** |  | 13d | 2014-01-06 | 2014-01-22 | 0d |
| 10 | 4.1 | Integrate Globalstar | manual | 6d | 2014-01-06 | 2014-01-13 |  |
| 11 | 4.2 | Integrate MF acoustic modem | manual | 8d | 2014-01-13 | 2014-01-22 |  |
| 12 | 5 | **Operations** |  | 226d | 2014-02-03 | 2014-12-15 | 0d |
| 13 | 5.1 | Rover status shakeout Station M | manual | 11d | 2014-02-03 | 2014-02-17 |  |
| 14 | 5.2 | SV3 sea trial | milestone, manual | 0d | 2014-02-04 | 2014-02-04 |  |
| 15 | 5.3 | EcoHAB | manual | 26d | 2014-03-28 | 2014-05-02 |  |
| 16 | 5.4 | WG Launch - R/V Nerissa | milestone, manual | 0d | 2014-04-01 | 2014-04-01 |  |
| 17 | 5.5 | WG Recovery - R/V Nerissa | milestone, manual | 0d | 2014-04-30 | 2014-04-30 |  |
| 18 | 5.6 | Rover status Smooth Ridge | manual | 12d | 2014-06-06 | 2014-06-23 |  |
| 19 | 5.7 | Rover status deployed Station M | manual | 8d | 2014-11-03 | 2014-11-12 |  |
| 20 | 5.8 | BEDs as available | manual | 5d | 2014-03-05 | 2014-03-11 |  |
| 21 | 5.9 | BEDs as available | manual | 7d | 2014-02-03 | 2014-02-11 |  |
| 22 | 5.10 | BEDs as available | manual | 5d | 2014-05-19 | 2014-05-23 |  |
| 23 | 5.11 | BEDs as available | manual | 5d | 2014-07-14 | 2014-07-18 |  |
| 24 | 5.12 | BEDs as available | manual | 5d | 2014-10-06 | 2014-10-10 |  |
| 25 | 5.13 | BEDs as available | manual | 6d | 2014-12-08 | 2014-12-15 |  |
| 26 | 5.14 | Aerostat Tests beach? | milestone, manual | 0d | 2014-06-02 | 2014-06-02 |  |
| 27 | 5.15 | Aerostat Tests Paragon? | milestone, manual | 0d | 2014-08-11 | 2014-08-11 |  |
